# SUB PROYECTO A4 Y PAMPA DEL TORO

Schedule from Primavera P6, 2022-12-22 to 2023-05-19, data date 2022-12-22.

## Calendars

- DiasCalendario: Mon-Sun 08:00-16:00.

## Schedule

| ID | WBS | Activity | Duration | Start | Finish | Predecessors | Total float | Free float |
| --- | --- | --- | --- | --- | --- | --- | --- | --- |
|  | 100 | **PAMPA DEL TORO** |  | 2023-01-05 | 2023-02-25 |  |  |  |
|  | 1 | **MEJORAMIENTO DE VIAS EXISTENTES** |  | 2023-01-05 | 2023-01-12 |  |  |  |
|  | 1 | **MOVIMIENTO DE TIERRAS** |  | 2023-01-05 | 2023-01-11 |  |  |  |
| A1000 |  | ROCE Y LIMPIEZA DE MALEZA | 2d | 2023-01-05 | 2023-01-06 | A1500 | 4d | 0d |
| A1010 |  | MEJORAMIENTO DE VIAS EXISTENTES | 5d | 2023-01-07 | 2023-01-11 | A1000 | 128d |  |
|  | 2 | **REPOSICION DE ESTRUCTURAS** |  | 2023-01-07 | 2023-01-09 |  |  |  |
| A1020 |  | DEMOLICIÓN DE ESTRUCTURAS EXISTENTES | 1d | 2023-01-07 | 2023-01-07 | A1000 | 4d | 0d |
| A1030 |  | REPOSICIÓN DE PASE DE AGUA TUBERÍA HDPE Ø=36" | 1d | 2023-01-08 | 2023-01-08 | A1020 | 4d | 0d |
| A1050 |  | SUMINISTRO Y MONTAJE DE LOSAS DE C°A° 1.6mx1.0mx0.20m EN PASE DE AGUA | 1d | 2023-01-08 | 2023-01-08 | A1020 | 131d |  |
| A1040 |  | REPOSICIÓN DE PASE DE AGUA TUBERÍA HDPE Ø=24" | 1d | 2023-01-09 | 2023-01-09 | A1030 | 4d | 0d |
|  | 3 | **ESTRUCTURAS DE CONCRETO** |  | 2023-01-10 | 2023-01-12 |  |  |  |
| A1070 |  | ENCOFRADO Y DESENCOFRADO NORMAL | 2d | 2023-01-10 | 2023-01-11 | A1040 | 4d | 0d |
| A1060 |  | CONCRETO 175 Kg/Cm2 | 1d | 2023-01-12 | 2023-01-12 | A1070 | 4d | 0d |
|  | 2 | **DIQUES Y PROTECCION DE CAUCE CON ENROCADO** |  | 2023-01-13 | 2023-02-08 |  |  |  |
|  | 1 | **DIQUE DE TIERRA COMPACTADA A4-PT-D-05** |  | 2023-01-13 | 2023-01-22 |  |  |  |
| A1080 |  | DESBROCE Y LIMPIEZA EN ZONA NO BOSCOSA | 1d | 2023-01-13 | 2023-01-13 | A1060 | 4d | 0d |
| A1090 |  | EXCAVACIÓN EN TERRENO NATURAL CON EQUIPO | 1d | 2023-01-14 | 2023-01-14 | A1080 | 4d | 0d |
| A1100 |  | PERFILADO Y COMPACTACIÓN EN ZONA DE CORTE | 1d | 2023-01-15 | 2023-01-15 | A1090 | 4d | 0d |
| A1110 |  | CONFORMACIÓN DE CUERPO DE DIQUE | 2d | 2023-01-16 | 2023-01-17 | A1100 | 4d | 0d |
| A1130 |  | GEOTEXTIL NO TEJIDO 400 G/M2, INC. COLOCACIÓN | 1d | 2023-01-18 | 2023-01-18 | A1110 | 4d | 0d |
| A1120 |  | CONFORMACIÓN DE MATERIAL GRANULAR EN CORONA DE DIQUE | 1d | 2023-01-19 | 2023-01-19 | A1130 | 4d | 0d |
| A1140 |  | COLOCACION Y ACOMODO DE ROCA EN UÑA DE DIQUE | 2d | 2023-01-20 | 2023-01-21 | A1120 | 4d | 0d |
| A1150 |  | COLOCACION Y ACOMODO DE ROCA EN TALUD DE DIQUE | 1d | 2023-01-22 | 2023-01-22 | A1140 | 4d | 0d |
|  | 2 | **DIQUE DE TIERRA COMPACTADA A4-PT-D-04** |  | 2023-01-23 | 2023-01-30 |  |  |  |
| A1160 |  | DESBROCE Y LIMPIEZA EN ZONA NO BOSCOSA | 1d | 2023-01-23 | 2023-01-23 | A1150 | 4d | 0d |
| A1170 |  | EXCAVACIÓN EN TERRENO NATURAL CON EQUIPO | 1d | 2023-01-24 | 2023-01-24 | A1160 | 4d | 0d |
| A1180 |  | PERFILADO Y COMPACTACIÓN EN ZONA DE CORTE | 1d | 2023-01-25 | 2023-01-25 | A1170 | 4d | 0d |
| A1190 |  | CONFORMACIÓN DE CUERPO DE DIQUE | 1d | 2023-01-26 | 2023-01-26 | A1180 | 4d | 0d |
| A1210 |  | GEOTEXTIL NO TEJIDO 400 G/M2, INC. COLOCACIÓN | 1d | 2023-01-27 | 2023-01-27 | A1190 | 4d | 0d |
| A1200 |  | CONFORMACIÓN DE MATERIAL GRANULAR EN CORONA DE DIQUE | 1d | 2023-01-28 | 2023-01-28 | A1210 | 4d | 0d |
| A1220 |  | COLOCACION Y ACOMODO DE ROCA EN UÑA DE DIQUE | 1d | 2023-01-29 | 2023-01-29 | A1200 | 4d | 0d |
| A1230 |  | COLOCACION Y ACOMODO DE ROCA EN TALUD DE DIQUE | 1d | 2023-01-30 | 2023-01-30 | A1220 | 4d | 0d |

| ID | WBS | Activity | Duration | Start | Finish | Predecessors | Total float | Free float |
| --- | --- | --- | --- | --- | --- | --- | --- | --- |
|  | 3 | **PROTECCION DE TALUDES** |  | 2023-01-31 | 2023-02-08 |  |  |  |
| A1240 |  | DESBROCE Y LIMPIEZA EN ZONA NO BOSCOSA | 1d | 2023-01-31 | 2023-01-31 | A1230 | 4d | 0d |
| A1250 |  | EXCAVACIÓN EN TERRENO NATURAL CON EQUIPO | 1d | 2023-02-01 | 2023-02-01 | A1240 | 4d | 0d |
| A1260 |  | PERFILADO Y COMPACTACIÓN EN ZONA DE CORTE | 1d | 2023-02-02 | 2023-02-02 | A1250 | 4d | 0d |
| A1270 |  | RELLENO ESTRUCTURAL CON MATERIAL PROPIO | 1d | 2023-02-03 | 2023-02-03 | A1260 | 4d | 0d |
| A1280 |  | GEOTEXTIL NO TEJIDO 400 G/M2, INC. COLOCACIÓN | 1d | 2023-02-04 | 2023-02-04 | A1270 | 4d | 0d |
| A1290 |  | COLOCACION Y ACOMODO DE ROCA EN UÑA DE DIQUE | 2d | 2023-02-05 | 2023-02-06 | A1280 | 4d | 0d |
| A1300 |  | COLOCACION Y ACOMODO DE ROCA EN TALUD DE DIQUE | 2d | 2023-02-07 | 2023-02-08 | A1290 | 4d | 0d |
|  | 3 | **REPOSICIÓN DE CAMINO DE ACCESO A4-RC-1** |  | 2023-02-09 | 2023-02-12 |  |  |  |
| A1310 |  | DESBROCE Y LIMPIEZA EN ZONA NO BOSCOSA | 1d | 2023-02-09 | 2023-02-09 | A1300 | 4d | 0d |
| A1320 |  | EXCAVACIÓN EN MATERIAL SUELTO CON EQUIPO | 1d | 2023-02-10 | 2023-02-10 | A1310 | 4d | 0d |
| A1330 |  | PERFILADO Y COMPACTACIÓN EN ZONA DE CORTE | 1d | 2023-02-11 | 2023-02-11 | A1320 | 4d | 0d |
| A1340 |  | MATERIAL AFIRMADO e=25 cm | 1d | 2023-02-12 | 2023-02-12 | A1330 | 4d | 0d |
|  | 4 | **PROTECCION DEL CAUCE CON ENROCADO)** |  | 2023-02-13 | 2023-02-19 |  |  |  |
| A1350 |  | DESBROCE Y LIMPIEZA EN ZONA NO BOSCOSA | 1d | 2023-02-13 | 2023-02-13 | A1340 | 4d | 0d |
| A1360 |  | EXCAVACIÓN EN MATERIAL SUELTO CON EQUIPO | 1d | 2023-02-14 | 2023-02-14 | A1350 | 4d | 0d |
| A1370 |  | PERFILADO Y COMPACTACIÓN CON EQUIPO DE FONDO DE EXCAVACIÓN | 1d | 2023-02-15 | 2023-02-15 | A1360 | 4d | 0d |
| A1380 |  | COLOCACION DE ROCA EN CAUCE | 4d | 2023-02-16 | 2023-02-19 | A1370 | 4d | 0d |
|  | 5 | **TRANSPORTE DE MATERIAL** |  | 2023-01-05 | 2023-02-18 |  |  |  |
| A1390 |  | TRANPORTE DE MATERIAL GRANULAR PARA DISTANCIAS <1KM | 39d | 2023-01-05 | 2023-02-12 | A1500 | 15d | 0d |
| A1400 |  | TRANPORTE DE MATERIAL GRANULAR PARA DISTANCIAS >1KM | 39d | 2023-01-05 | 2023-02-12 | A1390 SS | 96d |  |
| A1410 |  | TRANPORTE DE ROCA PARA DISTANCIAS <1KM | 45d | 2023-01-05 | 2023-02-18 | A1500 | 15d | 0d |
| A1420 |  | TRANPORTE DE ROCA PARA DISTANCIAS >1KM | 45d | 2023-01-05 | 2023-02-18 | A1410 SS | 15d | 0d |
| A1430 |  | TRANPORTE DE MATERIAL EXCEDENTE PARA DISTANCIAS <1KM | 45d | 2023-01-05 | 2023-02-18 | A1500 | 15d | 0d |
| A1440 |  | TRANPORTE DE MATERIAL EXCEDENTE PARA DISTANCIAS >1KM | 45d | 2023-01-05 | 2023-02-18 | A1430 SS | 15d | 0d |

| ID | WBS | Activity | Duration | Start | Finish | Predecessors | Total float | Free float |
| --- | --- | --- | --- | --- | --- | --- | --- | --- |
|  | 6 | **PROGRAMA DE CIERRE DE OBRA** |  | 2023-02-20 | 2023-02-25 |  |  |  |
| A1450 |  | ACONDICIONAMIENTO DE DEPOSITOS DE MATERIALES EXCEDENTES (DME) | 3d | 2023-02-20 | 2023-02-22 | A1380 | 83d | 0d |
| A1460 |  | RESTAURACIÓN DE ÁREAS DE INSTALACIONES PROVISIONALES | 3d | 2023-02-23 | 2023-02-25 | A1450 | 83d |  |
|  | 200 | **SUBPROYECTO A4** |  | 2022-12-22 | 2023-05-19 |  |  |  |
|  | 01 | **OBRAS PRELIMINARES** |  | 2022-12-22 | 2023-05-19 |  |  |  |
| A1470 |  | CARTEL DE IDENTIFICACIÓN OBRA 4.80 x 3.60 m. | 1d | 2022-12-22 | 2022-12-22 |  | 0d |  |
| A1480 |  | INSTALACIONES PROVISIONALES PARA LA OBRA | 13d | 2022-12-23 | 2023-01-04 | A1470 | 0d |  |
| A1490 |  | MANTENIMIENTO DE TRÁNSITO Y SEGURIDAD VIAL | 120d | 2023-01-20 | 2023-05-19 | A1530 | 0d |  |
|  | 02 | **TRABAJOS PRELIMINARES** |  | 2022-12-23 | 2023-05-04 |  |  |  |
| A1500 |  | MOVILIZACION Y DESMOVILIZACION DE EQUIPOS | 13d | 2022-12-23 | 2023-01-04 | A1480 SS | 0d |  |
| A1510 |  | TOPOGRAFÍA Y GEORREFERENCIACIÓN | 120d | 2023-01-05 | 2023-05-04 | A1500 | 0d |  |
|  | 03 | **MEJORAMIENTO DE VÍAS EXISTENTES** |  | 2023-01-05 | 2023-01-29 |  |  |  |
|  | 1 | **MOVIMIENTO DE TIERRAS** |  | 2023-01-05 | 2023-01-19 |  |  |  |
| A1520 |  | ROCE Y LIMPIEZA DE MALEZA | 5d | 2023-01-05 | 2023-01-09 | A1510 SS | 0d |  |
| A1530 |  | MEJORAMIENTO DE VIAS EXISTENTES | 15d | 2023-01-05 | 2023-01-19 | A1510 SS | 0d |  |
|  | 2 | **REPOSICION DE ESTRUCTURAS** |  | 2023-01-05 | 2023-01-24 |  |  |  |
| A1540 |  | DEMOLICIÓN DE ESTRUCTURAS EXISTENTES | 5d | 2023-01-05 | 2023-01-09 | A1510 SS | 110d | 0d |
| A1550 |  | REPOSICIÓN DE PASE DE AGUA TUBO HDPE Ø=24" | 5d | 2023-01-10 | 2023-01-14 | A1540 | 110d | 0d |
| A1560 |  | REPOSICIÓN DE PASE DE AGUA TUBO HDPE Ø=36" | 5d | 2023-01-15 | 2023-01-19 | A1550 | 110d | 0d |
| A1570 |  | SUMINISTRO Y MONTAJE DE PANELES DE C°A° 2.20mx1.0mx0.20m en Pase de Agua | 5d | 2023-01-20 | 2023-01-24 | A1560 | 115d |  |
|  | 3 | **CABEZAL DE ENTRADA Y SALIDA** |  | 2023-01-20 | 2023-01-29 |  |  |  |
| A1590 |  | ENCOFRADO Y DESENCOFRADO NORMAL | 5d | 2023-01-20 | 2023-01-24 | A1560 | 110d | 0d |
| A1580 |  | CONCRETO 175 Kg/Ccm2 | 5d | 2023-01-25 | 2023-01-29 | A1590 | 110d |  |
|  | 04 | **DESCOLMATACION DE CAUCE** |  | 2023-01-10 | 2023-01-29 |  |  |  |
|  | 1 | **DESBROCE Y LIMPIEZA EN ZONA NO BOSCOSA** |  | 2023-01-10 | 2023-01-14 |  |  |  |
| A1600 |  | DESBROCE Y LIMPIEZA EN ZONA NO BOSCOSA SUBPROYECTO A4 | 5d | 2023-01-10 | 2023-01-14 | A1520 | 0d |  |

| ID | WBS | Activity | Duration | Start | Finish | Predecessors | Total float | Free float |
| --- | --- | --- | --- | --- | --- | --- | --- | --- |
|  | 2 | **DESCOLMATACIÓN EN CAUCE NATURAL** |  | 2023-01-15 | 2023-01-29 |  |  |  |
| A1610 |  | DESCOLMATACIÓN DE CAUCE NATURAL EN RIO LACRAMARCA | 5d | 2023-01-15 | 2023-01-19 | A1600 | 110d | 0d |
| A1620 |  | DESCOLMATACIÓN DE CAUCE NATURAL EN BRAZO SECUNDARIO | 5d | 2023-01-20 | 2023-01-24 | A1610 | 110d | 0d |
| A1630 |  | DESCOLMATACIÓN DE CAUCE NATURAL EN QUEBRADA PAMPA DEL TORO | 5d | 2023-01-25 | 2023-01-29 | A1620 | 110d |  |
|  | 05 | **DIQUES DE TIERRA COMPACTADA CON ENROCADO** |  | 2023-01-15 | 2023-05-19 |  |  |  |
|  | 1 | **DIQUE DE TIERRA COMPACTADA A4-D-01** |  | 2023-01-15 | 2023-04-02 |  |  |  |
| A1640 |  | EXCAVACIÓN EN TERRENO NATURAL CON EQUIPO | 30d | 2023-01-15 | 2023-02-13 | A1600 | 0d |  |
| A1660 |  | PERFILADO Y COMPACTACIÓN EN ZONA DE CORTE | 18d | 2023-02-02 | 2023-02-19 | A1650 FF | 0d |  |
| A1650 |  | EXCAVACIÓN EN UÑA CON EQUIPO | 6d | 2023-02-14 | 2023-02-19 | A1640 | 0d |  |
| A1720 |  | PREPARACIÓN DE FUNDACIÓN DE CUERPO DE DIQUE | 1d | 2023-02-19 | 2023-02-19 | A1650 FF | 0d |  |
| A1670 |  | CONFORMACIÓN DE CUERPO DE DIQUE CON MATERIAL PROPIO | 1d | 2023-02-20 | 2023-02-20 | A1660, A1720 | 0d |  |
| A1690 |  | GEOTEXTIL NO TEJIDO 400 G/M2, INC. COLOCACIÓN | 11d | 2023-02-21 | 2023-03-03 | A1670 | 0d |  |
| A1680 |  | CONFORMACIÓN DE MATERIAL GRANULAR EN CORONA DE DIQUE | 8d | 2023-03-04 | 2023-03-11 | A1690 | 66d | 54d |
| A1700 |  | COLOCACION Y ACOMODO DE ROCA EN UÑA DE DIQUE | 22d | 2023-03-04 | 2023-03-25 | A1690 | 0d |  |
| A1710 |  | COLOCACION Y ACOMODO DE ROCA EN TALUD DE DIQUE | 30d | 2023-03-04 | 2023-04-02 | A1700 SS | 0d |  |
|  | 2 | **DIQUE DE TIERRA COMPACTADA A4-I-01** |  | 2023-04-15 | 2023-05-19 |  |  |  |
| A1730 |  | EXCAVACIÓN EN TERRENO NATURAL CON EQUIPO | 10d | 2023-04-15 | 2023-04-24 | A2160 | 0d |  |
| A1750 |  | PERFILADO Y COMPACTACIÓN EN ZONA DE CORTE | 7d | 2023-04-21 | 2023-04-27 | A1740 FF | 1d |  |
| A1740 |  | EXCAVACIÓN EN UÑA CON EQUIPO | 3d | 2023-04-25 | 2023-04-27 | A1730 | 0d |  |
| A1810 |  | PREPARACIÓN DE FUNDACIÓN DE CUERPO DE DIQUE | 1d | 2023-04-28 | 2023-04-28 | A1740 | 0d |  |
| A1760 |  | CONFORMACIÓN DE CUERPO DE DIQUE CON MATERIAL PROPIO | 1d | 2023-04-29 | 2023-04-29 | A1750, A1810 | 0d |  |
| A1780 |  | GEOTEXTIL NO TEJIDO 400 G/M2, INC. COLOCACIÓN | 5d | 2023-04-30 | 2023-05-04 | A1760 | 0d |  |
| A1770 |  | CONFORMACIÓN DE MATERIAL GRANULAR EN CORONA DE DIQUE | 3d | 2023-05-05 | 2023-05-07 | A1780, A1680 | 12d |  |
| A1790 |  | COLOCACION Y ACOMODO DE ROCA EN UÑA DE DIQUE | 10d | 2023-05-05 | 2023-05-14 | A1780 | 0d |  |
| A1800 |  | COLOCACION Y ACOMODO DE ROCA EN TALUD DE DIQUE | 15d | 2023-05-05 | 2023-05-19 | A1790 SS | 0d |  |

| ID | WBS | Activity | Duration | Start | Finish | Predecessors | Total float | Free float |
| --- | --- | --- | --- | --- | --- | --- | --- | --- |
|  | 3 | **DIQUE DE TIERRA COMPACTADA A4-I-02** |  | 2023-01-15 | 2023-03-07 |  |  |  |
| A1820 |  | EXCAVACIÓN EN TERRENO NATURAL CON EQUIPO | 21d | 2023-01-15 | 2023-02-04 | A1600 | 0d |  |
| A1830 |  | EXCAVACIÓN EN UÑA CON EQUIPO | 3d | 2023-02-05 | 2023-02-07 | A1820 | 0d |  |
| A1840 |  | PERFILADO Y COMPACTACIÓN EN ZONA DE CORTE | 9d | 2023-02-08 | 2023-02-16 | A1830 | 0d |  |
| A1900 |  | PREPARACIÓN DE FUNDACIÓN DE CUERPO DE DIQUE | 1d | 2023-02-08 | 2023-02-08 | A1830 | 8d |  |
| A1850 |  | CONFORMACIÓN DE CUERPO DE DIQUE CON MATERIAL PROPIO | 1d | 2023-02-17 | 2023-02-17 | A1840, A1900 | 0d |  |
| A1870 |  | GEOTEXTIL NO TEJIDO 400 G/M2, INC. COLOCACIÓN | 6d | 2023-02-18 | 2023-02-23 | A1850 | 0d |  |
| A1860 |  | CONFORMACIÓN DE MATERIAL GRANULAR EN CORONA DE DIQUE | 4d | 2023-02-24 | 2023-02-27 | A1870 | 77d | 39d |
| A1880 |  | COLOCACION Y ACOMODO DE ROCA EN UÑA DE DIQUE | 11d | 2023-02-24 | 2023-03-06 | A1870 | 0d |  |
| A1890 |  | COLOCACION Y ACOMODO DE ROCA EN TALUD DE DIQUE | 12d | 2023-02-24 | 2023-03-07 | A1880 SS | 0d |  |
|  | 4 | **DIQUE DE TIERRA COMPACTADA A4-BS-D-01** |  | 2023-03-08 | 2023-04-25 |  |  |  |
| A1910 |  | EXCAVACIÓN EN TERRENO NATURAL CON EQUIPO | 4d | 2023-03-08 | 2023-03-11 | A1890 | 0d |  |
| A1920 |  | EXCAVACIÓN EN UÑA CON EQUIPO | 2d | 2023-03-12 | 2023-03-13 | A1910 | 0d |  |
| A1930 |  | PERFILADO Y COMPACTACIÓN EN ZONA DE CORTE | 6d | 2023-03-14 | 2023-03-19 | A1920 | 0d |  |
| A1990 |  | PREPARACIÓN DE FUNDACIÓN DE CUERPO DE DIQUE | 1d | 2023-03-14 | 2023-03-14 | A1920 | 5d |  |
| A1940 |  | CONFORMACIÓN DE CUERPO DE DIQUE CON MATERIAL PROPIO | 14d | 2023-03-20 | 2023-04-02 | A1930, A1990 | 0d |  |
| A1960 |  | GEOTEXTIL NO TEJIDO 400 G/M2, INC. COLOCACIÓN | 5d | 2023-04-03 | 2023-04-07 | A1940 | 0d |  |
| A1950 |  | CONFORMACIÓN DE MATERIAL GRANULAR EN CORONA DE DIQUE | 4d | 2023-04-08 | 2023-04-11 | A1960, A1860 | 38d |  |
| A1970 |  | COLOCACION Y ACOMODO DE ROCA EN UÑA DE DIQUE | 18d | 2023-04-08 | 2023-04-25 | A1960 | 0d |  |
| A1980 |  | COLOCACION Y ACOMODO DE ROCA EN TALUD DE DIQUE | 11d | 2023-04-08 | 2023-04-18 | A1970 SS | 0d |  |
|  | 5 | **DIQUE DE TIERRA COMPACTADA A4-BS-I-01** |  | 2023-04-19 | 2023-05-19 |  |  |  |
| A2000 |  | EXCAVACIÓN EN TERRENO NATURAL CON EQUIPO | 2d | 2023-04-19 | 2023-04-20 | A1980 | 0d |  |
| A2010 |  | EXCAVACIÓN EN UÑA CON EQUIPO | 2d | 2023-04-21 | 2023-04-22 | A2000 | 0d |  |
| A2020 |  | PERFILADO Y COMPACTACIÓN EN ZONA DE CORTE | 3d | 2023-04-23 | 2023-04-25 | A2010 | 0d |  |
| A2080 |  | PREPARACIÓN DE FUNDACIÓN DE CUERPO DE DIQUE | 1d | 2023-04-23 | 2023-04-23 | A2010 | 2d |  |
| A2030 |  | CONFORMACIÓN DE CUERPO DE DIQUE CON MATERIAL PROPIO | 9d | 2023-04-26 | 2023-05-04 | A2020, A2080 | 0d |  |
| A2050 |  | GEOTEXTIL NO TEJIDO 400 G/M2, INC. COLOCACIÓN | 3d | 2023-05-05 | 2023-05-07 | A2030 | 0d |  |
| A2040 |  | CONFORMACIÓN DE MATERIAL GRANULAR EN CORONA DE DIQUE | 2d | 2023-05-08 | 2023-05-09 | A2050 | 10d |  |
| A2060 |  | COLOCACION Y ACOMODO DE ROCA EN UÑA DE DIQUE | 12d | 2023-05-08 | 2023-05-19 | A2050 | 0d |  |
| A2070 |  | COLOCACION Y ACOMODO DE ROCA EN TALUD DE DIQUE | 9d | 2023-05-08 | 2023-05-16 | A2060 SS | 3d |  |

| ID | WBS | Activity | Duration | Start | Finish | Predecessors | Total float | Free float |
| --- | --- | --- | --- | --- | --- | --- | --- | --- |
|  | 6 | **DIQUE DE TIERRA COMPACTADA A4-D-00** |  | 2023-04-03 | 2023-04-14 |  |  |  |
| A2090 |  | EXCAVACIÓN EN TERRENO NATURAL CON EQUIPO | 2d | 2023-04-03 | 2023-04-04 | A1710 | 0d |  |
| A2100 |  | EXCAVACIÓN EN UÑA CON EQUIPO | 1d | 2023-04-05 | 2023-04-05 | A2090 | 0d |  |
| A2110 |  | PERFILADO Y COMPACTACIÓN EN ZONA DE CORTE | 1d | 2023-04-06 | 2023-04-06 | A2100 | 0d |  |
| A2170 |  | PREPARACIÓN DE FUNDACIÓN DE CUERPO DE DIQUE | 1d | 2023-04-06 | 2023-04-06 | A2100 | 0d |  |
| A2120 |  | CONFORMACIÓN DE CUERPO DE DIQUE CON MATERIAL PROPIO | 1d | 2023-04-07 | 2023-04-07 | A2110, A2170 | 0d |  |
| A2140 |  | GEOTEXTIL NO TEJIDO 400 G/M2, INC. COLOCACIÓN | 1d | 2023-04-08 | 2023-04-08 | A2120 | 0d |  |
| A2130 |  | CONFORMACIÓN DE MATERIAL GRANULAR EN CORONA DE DIQUE | 1d | 2023-04-09 | 2023-04-09 | A2140 | 0d |  |
| A2150 |  | COLOCACION Y ACOMODO DE ROCA EN UÑA DE DIQUE | 3d | 2023-04-10 | 2023-04-12 | A2130 | 0d |  |
| A2160 |  | COLOCACION Y ACOMODO DE ROCA EN TALUD DE DIQUE | 5d | 2023-04-10 | 2023-04-14 | A2150 SS | 0d |  |
|  | 7 | **DIQUE DE TIERRA COMPACTADA A4-I-00** |  | 2023-04-03 | 2023-04-17 |  |  |  |
| A2180 |  | EXCAVACIÓN EN TERRENO NATURAL CON EQUIPO | 2d | 2023-04-03 | 2023-04-04 | A1710 | 32d | 0d |
| A2190 |  | EXCAVACIÓN EN UÑA CON EQUIPO | 1d | 2023-04-05 | 2023-04-05 | A2180 | 32d | 0d |
| A2200 |  | PERFILADO Y COMPACTACIÓN EN ZONA DE CORTE | 1d | 2023-04-06 | 2023-04-06 | A2190 | 32d | 0d |
| A2260 |  | PREPARACIÓN DE FUNDACIÓN DE CUERPO DE DIQUE | 1d | 2023-04-06 | 2023-04-06 | A2190 | 32d | 0d |
| A2210 |  | CONFORMACIÓN DE CUERPO DE DIQUE CON MATERIAL PROPIO | 1d | 2023-04-07 | 2023-04-07 | A2200, A2260 | 32d | 0d |
| A2230 |  | GEOTEXTIL NO TEJIDO 400 G/M2, INC. COLOCACIÓN | 1d | 2023-04-08 | 2023-04-08 | A2210 | 32d | 0d |
| A2220 |  | CONFORMACIÓN DE MATERIAL GRANULAR EN CORONA DE DIQUE | 1d | 2023-04-09 | 2023-04-09 | A2230 | 32d | 0d |
| A2240 |  | COLOCACION Y ACOMODO DE ROCA EN UÑA DE DIQUE | 3d | 2023-04-10 | 2023-04-12 | A2220 | 32d | 0d |
| A2250 |  | COLOCACION Y ACOMODO DE ROCA EN TALUD DE DIQUE | 5d | 2023-04-13 | 2023-04-17 | A2240, A2160 FF | 32d |  |
|  | 06 | **RAMPAS** |  | 2023-02-20 | 2023-03-06 |  |  |  |
| A2270 |  | EXCAVACIÓN EN TERRENO NATURAL CON EQUIPO | 5d | 2023-02-20 | 2023-02-24 | A1380 | 4d | 0d |
| A2280 |  | CONFORMACIÓN DE CUERPO DE RAMPA CON MATERIAL PROPIO | 5d | 2023-02-25 | 2023-03-01 | A2270 | 4d | 0d |
| A2290 |  | CONFORMACIÓN DE MATERIAL GRANULAR EN CORONA DE DIQUE | 5d | 2023-03-02 | 2023-03-06 | A2280 | 4d | 0d |

| ID | WBS | Activity | Duration | Start | Finish | Predecessors | Total float | Free float |
| --- | --- | --- | --- | --- | --- | --- | --- | --- |
|  | 07 | **MUROS DE CONCRETO ARMADO SOBRE CANAL HUACA NEPEÑA** |  | 2023-03-07 | 2023-04-15 |  |  |  |
|  | 1 | **MOVIMIENTO DE TIERRAS** |  | 2023-03-07 | 2023-04-15 |  |  |  |
| A2300 |  | EXCAVACIÓN ESTRUCTURAL PARA OBRAS DE ARTE | 5d | 2023-03-07 | 2023-03-11 | A2290 | 4d | 0d |
| A2310 |  | RELLENO ESTRUCTURAL PARA OBRAS DE ARTE CON MATERIAL PROPIO | 5d | 2023-04-11 | 2023-04-15 | A2370 | 4d | 0d |
|  | 2 | **OBRAS DE CONCRETO** |  | 2023-03-12 | 2023-04-10 |  |  |  |
| A2320 |  | CONCRETO F'C=100 Kg/cm2 | 5d | 2023-03-12 | 2023-03-16 | A2300 | 4d | 0d |
| A2340 |  | ENCOFRADO Y DESENCOFRADO | 5d | 2023-03-17 | 2023-03-21 | A2320 | 4d | 0d |
| A2350 |  | ACERO DE REFUERZO Fy=4200 Kg/cm2 | 5d | 2023-03-22 | 2023-03-26 | A2340 | 4d | 0d |
| A2330 |  | CONCRETO F'C=280 Kg/cm2 | 5d | 2023-03-27 | 2023-03-31 | A2350 | 4d | 0d |
| A2360 |  | SUMINISTRO E INSTALACIÓN DE TEKNOPORT e=3/4" | 5d | 2023-04-01 | 2023-04-05 | A2330 | 4d | 0d |
| A2370 |  | JUNTA con sellante expandible 1" x 3/4" | 5d | 2023-04-06 | 2023-04-10 | A2360 | 4d | 0d |
|  | 08 | **RETORNO EVACUADOR TOMA 4A** |  | 2023-04-16 | 2023-05-15 |  |  |  |
|  | 1 | **MOVIMIENTO DE TIERRAS** |  | 2023-04-16 | 2023-05-15 |  |  |  |
| A2380 |  | EXCAVACIÓN ESTRUCTURAL PARA OBRAS DE ARTE | 5d | 2023-04-16 | 2023-04-20 | A2310 | 4d | 0d |
| A2390 |  | CAMA DE ARENA | 5d | 2023-04-21 | 2023-04-25 | A2380 | 9d | 0d |
| A2400 |  | RELLENO ESTRUCTURAL PARA OBRAS DE ARTE CON MATERIAL PROPIO | 5d | 2023-05-11 | 2023-05-15 | A2420 | 4d |  |
|  | 2 | **OBRAS DE CONCRETO** |  | 2023-04-21 | 2023-05-10 |  |  |  |
| A2410 |  | CONCRETO F'C=100 Kg/cm2 | 5d | 2023-04-21 | 2023-04-25 | A2380 | 4d | 0d |
| A2430 |  | ENCOFRADO Y DESENCOFRADO | 5d | 2023-04-26 | 2023-04-30 | A2410 | 4d | 0d |
| A2440 |  | ACERO DE REFUERZO Fy=4200 Kg/cm2 | 5d | 2023-05-01 | 2023-05-05 | A2430 | 4d | 0d |
| A2420 |  | CONCRETO F'C=280 Kg/cm2 | 5d | 2023-05-06 | 2023-05-10 | A2440, A2450 | 4d | 0d |
|  | 3 | **TUBERIAS** |  | 2023-04-26 | 2023-04-30 |  |  |  |
| A2450 |  | SUMINISTRO E INSTALACIÓN DE TUBERÍA HDPE DN600 mm | 5d | 2023-04-26 | 2023-04-30 | A2390 | 9d | 5d |
|  | 4 | **COMPUERTAS Y VALVULAS** |  | 2023-05-11 | 2023-05-15 |  |  |  |
| A2460 |  | COMPUERTA DE CHARNELA DN600 mm | 5d | 2023-05-11 | 2023-05-15 | A2420 | 4d |  |

| ID | WBS | Activity | Type | Duration | Start | Finish | Predecessors | Total float |
| --- | --- | --- | --- | --- | --- | --- | --- | --- |
|  | 09 | **TRANSPORTE DE MATERIAL** |  |  | 2023-01-05 | 2023-05-04 |  |  |
| A2470 |  | TRANSPORTE DE MATERIAL GRANULAR PARA DISTANCIAS <1KM |  | 120d | 2023-01-05 | 2023-05-04 | A1390 SS | 15d |
| A2490 |  | TRANSPORTE DE ROCA PARA DISTANCIAS <1KM |  | 120d | 2023-01-05 | 2023-05-04 | A1410 SS | 15d |
| A2500 |  | TRANSPORTE DE ROCA PARA DISTANCIAS >1KM |  | 120d | 2023-01-05 | 2023-05-04 | A1420 SS | 15d |
| A2510 |  | TRANSPORTE DE MATERIAL EXCEDENTE PARA DISTANCIAS <1KM |  | 120d | 2023-01-05 | 2023-05-04 | A1430 SS | 15d |
| A2520 |  | TRANSPORTE DE MATERIAL EXCEDENTE PARA DISTANCIAS >1KM |  | 120d | 2023-01-05 | 2023-05-04 | A1440 SS | 15d |
|  | 10 | **PROGRAMA DE CIERRE DE OBRA** |  |  | 2023-03-21 | 2023-05-19 |  |  |
| A2530 |  | ACONDICIONAMIENTO DE DEPOSITOS DE MATERIALES EXCEDENTES (DME) |  | 60d | 2023-03-21 | 2023-05-19 | A2470 FF, A2490 FF, A2500 FF, A2510 FF, A2520 FF, A1790 FF, A1800 FF, A1770 FF, A1950 FF, A1970 FF, A2060 FF, A2070 FF, A1490 FF | 0d |
| A2540 |  | RESTAURACIÓN DE ÁREAS DE INSTALACIONES PROVISIONALES |  | 3d | 2023-05-17 | 2023-05-19 | A2530 FF, A1510 | 0d |
|  | 11 | **SEGURIDAD Y SALUD OCUPACIONAL** |  |  | 2022-12-23 | 2023-05-19 |  |  |
| A2550 |  | SEGURIDAD Y SALUD OCUPACIONAL |  | 140d | 2022-12-23 | 2023-05-11 | A1480 SS | 8d |
| A2560 |  | IMPLEMENTACIÓN DEL PLAN PARA LA VIGILANCIA, PREVENCIÓN Y CONTROL DE COVID-19 EN EL TRABAJO |  | 130d | 2023-01-05 | 2023-05-14 | A1480 | 5d |
| A2570 |  | FIN | milestone | 0d | 2023-05-19 | 2023-05-19 | A2530, A2540, A2250, A2460, A2550, A2560, A1390, A1400, A1410, A1420, A1430, A1440, A1380, A2400, A1460 | 0d |
